# Sint-Barbaracollege

Schedule from MS Project, 2012-02-06 to 2012-09-21, costs in €.
Final proyect
KAHO Sint-Lieven

## Calendars

- My project: Mon-Fri 07:00-11:30, 12:00-15:30; Sat-Sun off. Exceptions (off unless hours are given): 2012-02-14 (Valentine), 2012-04-08 (Easter), 2012-04-09 (Easter Monday), 2012-05-01 (Labour day), 2012-05-13 (Mother's day), 2012-05-17 (Ascension), 2012-05-27 (Pentecost), 2012-05-28 (Pentecost Monday), 2012-06-10 (Father's day), 2012-07-11 (Day of the Flemish Community), 2012-07-21 (National Holiday Belgium), 2012-08-15 (Assumption of Mary).

## Resources

| Resource | Group | Unit | Rate |
| --- | --- | --- | --- |
| 1st official in construction | Workers |  | 29.78 |
| Ordinary armor assembler pawn | Workers |  | 31.08 |
| Specializated pawn in construction | Workers |  | 28.94 |
| Ordinary pawn in construction | Workers |  | 28.47 |
| Specialist in iron | Workers |  | 24.05 |
| Official armor assembler | Workers |  | 31.08 |
| 1st official in plumber | Workers |  | 25.23 |
| Backhoe | Machine |  | 87 |
| Truck | Machine |  | 49.05 |
| Mixer truck | Machine |  | 102.04 |
| Vibrator | Machine |  | 1.42 |
| Cost demolition | Subcontractors |  |  |
| Concrete | Material | m3 | 61.33 |
| 1st official in iron | Workers |  | 20.95 |
| Cost crane setup/remove | Subcontractors |  |  |
| Cost glass wall | Subcontractors |  |  |
| Iron | Material | kg | 0.91 |
| Bricks | Material | pce | 0.17 |
| Concrete bricks | Material | m2 | 4.2 |
| Formwork | Material | m2 | 21.31 |
| Insulation | Material | m2 | 6.1 |
| Acoustical isolation | Material | m2 | 5.4 |
| Vapour barrier (Polyethilene plastic sheet) | Material | m2 | 1.25 |
| EPDM | Material | m2 | 9.15 |
| Grave | Material | m2 | 4.51 |
| Scaffold | Material | pce | 24.65 |
| Prefabricated slab | Material | m2 | 32 |
| Prefabricated pillar | Material | u | 120 |
| Adjustable support | Material | m2 | 11.25 |
| Tiles | Material | m2 | 8.03 |
| Pipes | Material | m. | 1.19 |
| Lean concrete | Material | m3 | 49.67 |
| Cement mortar | Material | m3 | 115.3 |
| Strut | Material | pce | 11.07 |
| Galvanized steel sheet | Material | m2 | 16.45 |
| Metallic beam | Material | pce | 25.21 |
| Crane subcontractor | Subcontractors |  |  |
| Glass wall subcontractor | Subcontractors |  |  |
| Demolition subcontractor | Subcontractors |  |  |
| Rental crane | Subcontractors |  | 6.25 |

## Schedule

| ID | WBS | Task | Type | Duration | Start | Finish | Predecessors | Total slack | Free slack | Resources | Work | Cost |
| --- | --- | --- | --- | --- | --- | --- | --- | --- | --- | --- | --- | --- |
| 1 | 1 | Beggining | milestone | 0d | 2012-02-06 07:00 | 2012-02-06 07:00 |  | 0d |  |  |  |  |
| 2 | 2 | **F.01 - Demolition** |  | 15d | 2012-02-06 07:00 | 2012-02-27 15:30 |  | 0d |  |  | 120h | 10,000 |
| 3 | 2.1 | Demolition of the existent building and debris transport |  | 15d | 2012-02-06 07:00 | 2012-02-27 15:30 | 1 | 0d |  | Cost demolition [0.8%]; Demolition subcontractor | 120h | 10,000 |
| 4 | 3 | **F.02 - Previous actions** |  | 1.25d | 2012-02-28 07:00 | 2012-02-29 09:00 |  | 0d |  |  | 20h | 569.4 |
| 5 | 3.1 | Fencing and signaling the site |  | 10h | 2012-02-28 07:00 | 2012-02-29 09:00 | 3 | 0d |  | Ordinary pawn in construction [200%] | 20h | 569.4 |
| 6 | 4 | **F.03 - Gym's foundation** |  | 18.81d | 2012-02-28 07:00 | 2012-03-23 14:00 |  | 1d |  |  | 381.23h | 45,040.03 |
| 7 | 4.1 | Excavation in gym zone |  | 4.5h | 2012-02-28 07:00 | 2012-02-28 11:30 | 3 | 1d | 0d | Ordinary pawn in construction; 1st official in construction; Backhoe; Truck [200%] | 18h | 874.35 |
| 8 | 4.2 | Excavation for gym's sewerage |  | 0.5h | 2012-02-28 08:48 | 2012-02-28 09:18 | 7SS+4% | 1d | 0d | 1st official in construction; Ordinary pawn in construction; Backhoe; Truck | 2h | 97.15 |
| 9 | 4.3 | Gym's sewerage installation |  | 9h | 2012-02-29 09:00 | 2012-03-01 10:00 | 8SS+4%, 5 | 0d |  | 1st official in construction; 1st official in plumber; Ordinary pawn in construction; Pipes [58 m.] | 27h | 820.34 |
| 10 | 4.4 | Placement of lean concrete |  | 5h | 2012-02-29 10:30 | 2012-03-01 07:30 | 12 | 0d |  | 1st official in construction; Ordinary pawn in construction; Mixer truck; Lean concrete [59.4 m3] | 15h | 3,751.85 |
| 11 | 4.5 | Placement of insulation (12 cm.) |  | 24h | 2012-03-05 07:30 | 2012-03-08 07:30 | 10FS+2d | 0d |  | 1st official in construction; Ordinary pawn in construction; Insulation [594.18 m2] | 48h | 5,022.5 |
| 12 | 4.6 | Placement of insulation as lost formwork in borders |  | 1.5h | 2012-02-29 09:00 | 2012-02-29 10:30 | 9SS | 0d |  | 1st official in construction; Specializated pawn in construction; Insulation [31.63 m2] | 3h | 281.02 |
| 13 | 4.7 | Placement of foundation armor |  | 61h | 2012-03-08 07:30 | 2012-03-19 13:00 | 11 | 0d |  | Official armor assembler; Ordinary armor assembler pawn [300%]; Iron [15175.5 kg] | 244h | 21,393.22 |
| 14 | 4.8 | Concrete placing/Vibration |  | 16.5h | 2012-03-19 13:00 | 2012-03-21 13:30 | 13 | 0d |  | 1st official in construction; Ordinary pawn in construction [200%]; Mixer truck; Vibrator; Concrete [202.34 m3] | 22.73h | 12,726.97 |
| 15 | 4.9 | Fill the hole in borders with ground |  | 0.5h | 2012-03-23 13:30 | 2012-03-23 14:00 | 14FS+2d | 1.59d | 1.25d | 1st official in construction; Ordinary pawn in construction; Backhoe | 1.5h | 72.62 |
| 16 | 5 | **F.04 - Classes foundation** |  | 19.77d | 2012-02-28 09:18 | 2012-03-27 07:30 |  | 0.34d |  |  | 294h | 30,145.99 |
| 17 | 5.1 | Excavation in classes |  | 3h | 2012-02-28 09:18 | 2012-02-28 12:48 | 8 | 5.69d | 0d | 1st official in construction; Ordinary pawn in construction; Backhoe; Truck | 12h | 582.9 |
| 18 | 5.2 | Excavation for classes sewerage |  | 0.5h | 2012-02-28 10:30 | 2012-02-28 11:00 | 17SS+4% | 5.69d | 0d | 1st official in construction; Ordinary pawn in construction; Backhoe; Truck | 2h | 97.15 |
| 19 | 5.3 | Classes sewerage installation |  | 14.5h | 2012-03-01 10:00 | 2012-03-05 08:30 | 18SS+4%, 9 | 3.77d | 0d | 1st official in construction; Ordinary pawn in construction; 1st official in plumber; Pipes [93.5 m.] | 43.5h | 1,321.72 |
| 20 | 5.4 | Placement of lean concrete |  | 3h | 2012-03-05 10:00 | 2012-03-05 13:30 | 22 | 3.77d | 0d | 1st official in construction; Ordinary pawn in construction [200%]; Lean concrete [37.12 m3]; Mixer truck | 12h | 2,410.03 |
| 21 | 5.5 | Placement of insulation (12 cm.) |  | 15h | 2012-03-07 13:30 | 2012-03-09 12:30 | 20FS+2d | 3.77d | 0d | 1st official in construction; Ordinary pawn in construction; Insulation [371.25 m2] | 30h | 3,138.38 |
| 22 | 5.6 | Placement of insulation as lost formwork in borders |  | 1.5h | 2012-03-05 08:30 | 2012-03-05 10:00 | 19 | 3.77d | 0d | 1st official in construction; Specializated pawn in construction; Insulation [25.61 m2] | 3h | 244.3 |
| 23 | 5.7 | Placement of foundation armor |  | 37.5h | 2012-03-09 12:30 | 2012-03-16 09:30 | 21 | 3.77d | 0d | Official armor assembler; Ordinary armor assembler pawn [300%]; Iron [9259.5 kg] | 150h | 13,088.15 |
| 24 | 5.8 | Concrete placing/Vibration |  | 10h | 2012-03-21 13:30 | 2012-03-22 15:30 | 23, 14 | 0.34d | 0d | 1st official in construction; Ordinary pawn in construction; Mixer truck; Vibrator; Concrete [123.49 m3] | 40h | 9,190.74 |
| 25 | 5.9 | Fill the hole in borders with ground |  | 0.5h | 2012-03-27 07:00 | 2012-03-27 07:30 | 24FS+2d | 0.34d | 0d | 1st official in construction; Ordinary pawn in construction; Backhoe | 1.5h | 72.62 |

| ID | WBS | Task | Duration | Start | Finish | Predecessors | Total slack | Free slack | Resources | Work | Cost |
| --- | --- | --- | --- | --- | --- | --- | --- | --- | --- | --- | --- |
| 26 | 6 | **F.05 - Theater building foundation** | 15.31d | 2012-02-28 11:00 | 2012-03-20 14:00 |  | 13.2d |  |  | 205.5h | 25,580.21 |
| 27 | 6.1 | Excavation in theater's place | 2.5h | 2012-02-28 11:00 | 2012-02-28 14:00 | 18 | 16.71d | 0d | 1st official in construction; Ordinary pawn in construction; Backhoe; Truck | 10h | 485.75 |
| 28 | 6.2 | Excavation for theater's sewerage | 1h | 2012-02-28 12:30 | 2012-02-28 13:30 | 27SS+4% | 16.71d | 3.51d | 1st official in construction; Ordinary pawn in construction; Backhoe; Truck | 4h | 194.3 |
| 29 | 6.3 | Theater sewerage installation | 15.5h | 2012-03-05 08:30 | 2012-03-07 08:00 | 28SS+4%, 19 | 13.2d | 0d | 1st official in construction; Ordinary pawn in construction; 1st official in plumber; Pipes [101.5 m.] | 46.5h | 1,414.72 |
| 30 | 6.4 | Placement of lean concrete | 3h | 2012-03-07 08:00 | 2012-03-07 11:00 | 29 | 13.2d | 0d | 1st official in construction; Ordinary pawn in construction [200%]; Lean concrete [34.14 m3] | 9h | 1,955.89 |
| 31 | 6.5 | Placement of insulation (12 cm.) | 14h | 2012-03-09 11:00 | 2012-03-13 09:00 | 30FS+2d | 13.2d | 0d | 1st official in construction; Ordinary pawn in construction; Insulation [341.37 m2] | 28h | 2,897.86 |
| 32 | 6.6 | Placement of foundation armor | 35h | 2012-03-13 09:00 | 2012-03-19 12:30 | 31 | 13.2d | 0d | Official armor assembler; Ordinary armor assembler pawn; Iron [8635.5 kg] | 70h | 10,033.91 |
| 33 | 6.7 | Concrete placing/Vibration | 9.5h | 2012-03-19 12:30 | 2012-03-20 14:00 | 32 | 13.2d | 2.62d | 1st official in construction; Ordinary pawn in construction; Concrete [115.14 m3]; Mixer truck; Vibrator | 38h | 8,597.78 |
| 34 | 7 | **F.06 - Gym's structure** | 13.53d | 2012-03-26 13:30 | 2012-04-16 09:12 |  | 0d |  |  | 589h | 55,041.61 |
| 35 | 7.1 | Self erecting tower crane installation (in playground) | 2h | 2012-03-27 07:30 | 2012-03-27 09:30 | 15, 25 | 0.34d |  | Cost crane setup/remove [5%]; Crane subcontractor | 2h | 1,000 |
| 36 | 7.2 | **Party walls in gym's zone** | 10.59d | 2012-03-26 13:30 | 2012-04-11 09:42 |  | 0d |  |  | 386.5h | 40,993.03 |
| 37 | 7.2.1 | Placement of insulation in existent walls as lost formwork | 24h | 2012-03-26 13:30 | 2012-03-29 13:30 | 14FS+3d | 0d |  | 1st official in construction; Ordinary pawn in construction; Insulation [595 m2] | 48h | 5,027.5 |
| 38 | 7.2.2 | Placement of armor | 8h | 2012-03-27 12:42 | 2012-03-28 12:42 | 37SS+3%, 35 | 0d |  | Official armor assembler; Ordinary armor assembler pawn [300%]; Iron [1958 kg] | 32h | 2,776.34 |
| 39 | 7.2.3 | Placement of external formwork | 24h | 2012-03-28 12:42 | 2012-04-02 12:42 | 38 | 0d |  | 1st official in construction; Specializated pawn in construction [500%]; Formwork [595 m2] | 144h | 16,866.97 |
| 40 | 7.2.4 | Concrete placing/Vibration | 14.5h | 2012-04-02 12:42 | 2012-04-04 10:42 | 39 | 0d |  | 1st official in construction; Ordinary pawn in construction [200%]; Concrete [178.5 m3]; Mixer truck; Vibrator | 72.5h | 13,705.01 |
| 41 | 7.2.5 | Take away external formwork | 15h | 2012-04-06 10:42 | 2012-04-11 09:42 | 40FS+2d | 0d |  | 1st official in construction; Specializated pawn in construction [500%] | 90h | 2,617.2 |
| 42 | 7.3 | **Concrete pillars 1st level** | 3.56d | 2012-03-28 12:42 | 2012-04-03 08:42 |  | 105.29d |  |  | 23.5h | 1,870.15 |
| 43 | 7.3.1 | Placement of armor | 1.5h | 2012-03-28 12:42 | 2012-03-28 14:12 | 35, 38 | 105.29d | 0d | Official armor assembler; Ordinary armor assembler pawn [300%]; Iron [288 kg] | 6h | 448.56 |
| 44 | 7.3.2 | Placement of formwork | 1.5h | 2012-03-28 14:12 | 2012-03-29 07:12 | 43 | 105.29d | 0d | 1st official in construction; Specializated pawn in construction [500%]; Formwork [33.6 m2] | 9h | 977.74 |
| 45 | 7.3.3 | Concrete placing/Vibration | 0.5h | 2012-03-29 07:12 | 2012-03-29 07:42 | 44 | 105.29d | 0d | 1st official in construction; Ordinary pawn in construction [200%]; Concrete [2.88 m3]; Mixer truck; Vibrator | 2.5h | 271.72 |
| 46 | 7.3.4 | Take away formwork | 1h | 2012-04-03 07:42 | 2012-04-03 08:42 | 45FS+3d | 105.29d | 0d | 1st official in construction; Ordinary pawn in construction [500%] | 6h | 172.13 |
| 47 | 7.4 | Gym's dressing room's wall (concrete bricks) | 20.5h | 2012-04-11 09:42 | 2012-04-13 14:42 | 41 | 0d |  | 1st official in construction; Specializated pawn in construction [300%]; Concrete bricks [90.9 m2]; Cement mortar [1.36 m3] | 82h | 2,928.89 |
| 48 | 7.5 | **Concrete beams** | 8.06d | 2012-04-03 08:42 | 2012-04-16 09:12 |  | 105.29d |  |  | 48h | 4,351.99 |
| 49 | 7.5.1 | Placement of formwork and struts | 4h | 2012-04-03 08:42 | 2012-04-03 13:12 | 46 | 105.29d | 0d | 1st official in construction; Specializated pawn in construction [500%]; Formwork [88.38 m2]; Strut [37 pce] | 24h | 2,990.89 |
| 50 | 7.5.2 | Placement of armor | 1h | 2012-04-03 13:12 | 2012-04-03 14:12 | 49 | 105.29d | 0d | Official armor assembler; Ordinary armor assembler pawn [300%]; Iron [170.7 kg] | 4h | 279.66 |
| 51 | 7.5.3 | Concrete placing/Vibration | 1h | 2012-04-03 14:12 | 2012-04-03 15:12 | 50 | 105.29d | 0d | 1st official in construction; Ordinary pawn in construction [200%]; Concrete [7.42 m3]; Mixer truck; Vibrator | 5h | 645.25 |
| 52 | 7.5.4 | Take away formwork | 2.5h | 2012-04-13 15:12 | 2012-04-16 09:12 | 51FS+7d | 105.29d | 0d | 1st official in construction; Specializated pawn in construction [500%] | 15h | 436.2 |

| ID | WBS | Task | Duration | Start | Finish | Predecessors | Total slack | Free slack | Resources | Work | Cost |
| --- | --- | --- | --- | --- | --- | --- | --- | --- | --- | --- | --- |
| 53 | 7.6 | **Gym's stairs** | 0.19d | 2012-04-13 14:42 | 2012-04-16 07:42 |  | 0d |  |  | 4.5h | 454.15 |
| 54 | 7.6.1 | Placement of prefabricated stairs' slabs with struts | 1.5h | 2012-04-13 14:42 | 2012-04-16 07:42 | 47 | 0d |  | 1st official in construction; Ordinary pawn in construction; Specializated pawn in construction; Prefabricated slab [6.3 m2]; Strut [11 pce] | 4.5h | 454.15 |
| 55 | 7.7 | **Concrete pillars 2nd level** | 4.06d | 2012-04-03 08:42 | 2012-04-10 09:12 |  | 105.91d |  |  | 42.5h | 3,443.4 |
| 56 | 7.7.1 | Placement of armor | 2.5h | 2012-04-03 08:42 | 2012-04-03 11:12 | 49SS | 105.97d | 0d | Official armor assembler; Ordinary armor assembler pawn [300%]; Iron [540 kg] | 10h | 802.2 |
| 57 | 7.7.2 | Placement of formwork | 3h | 2012-04-03 11:12 | 2012-04-03 14:42 | 56 | 105.97d | 0.06d | 1st official in construction; Specializated pawn in construction [500%]; Formwork [63 m2] | 18h | 1,865.97 |
| 58 | 7.7.3 | Concrete placing/Vibration | 0.5h | 2012-04-03 15:12 | 2012-04-04 07:12 | 57, 51 | 105.91d | 0d | 1st official in construction; Ordinary pawn in construction [200%]; Concrete [5.4 m3]; Mixer truck; Vibrator | 2.5h | 426.27 |
| 59 | 7.7.4 | Take away formwork | 2h | 2012-04-10 07:12 | 2012-04-10 09:12 | 58FS+3d | 105.91d | 0d | 1st official in construction; Specializated pawn in construction [500%] | 12h | 348.96 |
| 60 | 8 | **F.07 - Vertical elements** | 45.12d | 2012-03-09 12:30 | 2012-05-15 13:30 |  | 22.01d |  |  | 988.5h | 68,239.26 |
| 61 | 8.1 | **Concrete pillars in theater** | 3.44d | 2012-03-22 12:30 | 2012-03-28 07:30 |  | 55.65d |  |  | 18h | 1,117.67 |
| 62 | 8.1.1 | Placement of armor | 1h | 2012-03-22 12:30 | 2012-03-22 13:30 | 32FS+3d | 55.65d | 0d | Official armor assembler; Ordinary armor assembler pawn [300%]; Iron [154 kg] | 4h | 264.46 |
| 63 | 8.1.2 | Placement of formwork | 1h | 2012-03-22 13:30 | 2012-03-22 14:30 | 62 | 55.65d | 0d | 1st official in construction; Specializated pawn in construction [500%]; Formwork [14.4 m2] | 6h | 481.34 |
| 64 | 8.1.3 | Concrete placing/Vibration | 1h | 2012-03-22 14:30 | 2012-03-22 15:30 | 63 | 55.65d | 0d | 1st official in construction; Ordinary pawn in construction [200%]; Concrete [1.54 m3]; Mixer truck; Vibrator | 5h | 284.63 |
| 65 | 8.1.4 | Take away formwork | 0.5h | 2012-03-28 07:00 | 2012-03-28 07:30 | 64FS+3d | 55.65d | 0d | 1st official in construction; Specializated pawn in construction [500%] | 3h | 87.24 |
| 66 | 8.2 | **Prefabricated concrete pillars in playground** | 0.19d | 2012-03-09 12:30 | 2012-03-09 14:00 |  | 132.12d |  |  | 6h | 596.58 |
| 67 | 8.2.1 | Placement of armor for foundation | 0.5h | 2012-03-09 12:30 | 2012-03-09 13:00 | 23SS | 132.12d | 0d | Official armor assembler; Ordinary armor assembler pawn [300%]; Iron [90 kg] | 2h | 144.06 |
| 68 | 8.2.2 | Placement of prefabricated pillars | 0.5h | 2012-03-09 13:00 | 2012-03-09 13:30 | 67 | 132.12d | 0d | 1st official in construction; Specializated pawn in construction [200%]; Prefabricated pillar [2 u] | 1.5h | 283.83 |
| 69 | 8.2.3 | Concrete placing /Vibration | 0.5h | 2012-03-09 13:30 | 2012-03-09 14:00 | 68 | 132.12d | 78.31d | 1st official in construction; Ordinary pawn in construction [200%]; Concrete [1.2 m3]; Mixer truck; Vibrator | 2.5h | 168.69 |
| 70 | 8.3 | **Party walls in classes' zone (until 1st floor)** | 2.8d | 2012-03-27 07:30 | 2012-03-29 14:24 |  | 10.57d |  |  | 36h | 3,674.84 |
| 71 | 8.3.1 | Placement of insulation in existent walls as lost formwork | 3h | 2012-03-27 07:30 | 2012-03-27 10:30 | 25 | 10.57d | 0d | 1st official in construction; Ordinary pawn in construction; Insulation [61.28 m2] | 6h | 548.56 |
| 72 | 8.3.2 | Placement of armor | 1h | 2012-03-27 08:24 | 2012-03-27 09:24 | 71SS+3% | 10.97d | 0d | Official armor assembler; Ordinary armor assembler pawn [300%]; Iron [134.75 kg] | 4h | 246.94 |
| 73 | 8.3.3 | Placement of external formwork | 3h | 2012-03-27 09:24 | 2012-03-27 12:54 | 72 | 11.41d | 0d | 1st official in construction; Specializated pawn in construction [500%]; Formwork [61.28 m2] | 18h | 1,829.32 |
| 74 | 8.3.4 | Concrete placing/Vibration | 1h | 2012-03-27 12:54 | 2012-03-27 13:54 | 73 | 12.16d | 0d | 1st official in construction; Ordinary pawn in construction [200%]; Concrete [12.25 m3]; Mixer truck; Vibrator | 5h | 941.47 |
| 75 | 8.3.5 | Take away formwork | 0.5h | 2012-03-29 13:54 | 2012-03-29 14:24 | 74FS+2d | 93.54d | 0d | 1st official in construction; Specializated pawn in construction [500%]; Formwork [1 m2] | 3h | 108.55 |
| 76 | 8.4 | **Party walls in theater's zone (until 2nd floor)** | 4.26d | 2012-03-27 10:30 | 2012-04-02 13:06 |  | 10.57d |  |  | 104h | 10,111.45 |
| 77 | 8.4.1 | Placement of insulation in existent walls as lost formwork | 7h | 2012-03-27 10:30 | 2012-03-28 09:30 | 33FS+2d, 71 | 10.57d | 0d | 1st official in construction; Ordinary pawn in construction; Insulation [168.09 m2] | 14h | 1,433.1 |
| 78 | 8.4.2 | Placement of armor | 1.5h | 2012-03-27 13:06 | 2012-03-27 14:36 | 77SS+3%, 72 | 10.57d | 0d | Official armor assembler; Ordinary armor assembler pawn [300%]; Iron [297.69 kg] | 6h | 457.38 |
| 79 | 8.4.3 | Placement of external formwork | 7h | 2012-03-27 14:36 | 2012-03-28 13:36 | 78, 73 | 11.2d | 0d | 1st official in construction; Specializated pawn in construction [500%]; Formwork [168.09 m2] | 42h | 4,803.36 |
| 80 | 8.4.4 | Concrete placing/Vibration | 3h | 2012-03-28 13:36 | 2012-03-29 08:06 | 79, 74 | 11.2d | 0d | 1st official in construction; Ordinary pawn in construction [200%]; Concrete [33.62 m3]; Mixer truck; Vibrator | 15h | 2,632.45 |
| 81 | 8.4.5 | Take away formwork | 4.5h | 2012-04-02 08:06 | 2012-04-02 13:06 | 80FS+2d | 46.64d | 0d | 1st official in construction; Specializated pawn in construction [500%] | 27h | 785.16 |
| 82 | 8.5 | Brick walls in classes | 69h | 2012-03-29 13:54 | 2012-04-12 10:24 | 25, 75SS | 93.54d | 0d | 1st official in construction; Specializated pawn in construction [300%]; Bricks [13153 pce]; Cement mortar [4.99 m3] | 276h | 10,856.76 |

| ID | WBS | Task | Duration | Start | Finish | Predecessors | Total slack | Free slack | Resources | Work | Cost |
| --- | --- | --- | --- | --- | --- | --- | --- | --- | --- | --- | --- |
| 83 | 8.6 | **Concrete walls in theater Zone 7-8** | 5.06d | 2012-03-27 14:36 | 2012-04-03 15:06 |  | 10.57d |  |  | 160.5h | 14,505.19 |
| 84 | 8.6.1 | Placement of armor | 10h | 2012-03-27 14:36 | 2012-03-29 08:06 | 33FS+2d, 78 | 10.57d | 0d | Official armor assembler; Ordinary armor assembler pawn [300%]; Iron [2438.67 kg] | 40h | 3,462.39 |
| 85 | 8.6.2 | Placement of formwork | 11h | 2012-03-28 10:06 | 2012-03-29 13:36 | 84SS+4% | 10.57d | 0d | 1st official in construction; Specializated pawn in construction [500%]; Formwork [270.63 m2] | 66h | 7,686.41 |
| 86 | 8.6.3 | Concrete placing/Vibration | 2.5h | 2012-03-29 13:36 | 2012-03-30 07:36 | 85, 80 | 10.57d | 0d | 1st official in construction; Ordinary pawn in construction [200%]; Concrete [27.06 m3]; Mixer truck; Vibrator | 12.5h | 2,135.04 |
| 87 | 8.6.4 | Take away formwork | 7h | 2012-04-03 07:36 | 2012-04-03 15:06 | 86FS+2d | 10.57d | 0d | 1st official in construction; Specializated pawn in construction [500%] | 42h | 1,221.36 |
| 88 | 8.7 | **Concrete walls in theater Zone 10-11** | 8.75d | 2012-03-29 08:06 | 2012-04-11 14:36 |  | 10.57d |  |  | 190h | 17,364.95 |
| 89 | 8.7.1 | Placement of armor | 13h | 2012-03-29 08:06 | 2012-03-30 13:36 | 84 | 12.76d | 2.19d | Official armor assembler; Ordinary armor assembler pawn [300%]; Iron [3134.7 kg] | 52h | 4,468.74 |
| 90 | 8.7.2 | Placement of formwork | 12.5h | 2012-04-03 15:06 | 2012-04-05 11:06 | 89, 87 | 10.57d | 0d | 1st official in construction; Specializated pawn in construction [500%]; Formwork [310.31 m2] | 75h | 8,793.71 |
| 91 | 8.7.3 | Concrete placing/Vibration | 3h | 2012-04-05 11:06 | 2012-04-05 14:36 | 90 | 10.57d | 0d | 1st official in construction; Ordinary pawn in construction [200%]; Concrete [34.83 m3]; Mixer truck; Vibrator | 15h | 2,706.66 |
| 92 | 8.7.4 | Take away formwork | 8h | 2012-04-10 14:36 | 2012-04-11 14:36 | 91FS+2d | 10.57d | 0d | 1st official in construction; Specializated pawn in construction [500%] | 48h | 1,395.84 |
| 93 | 8.8 | Brick walls in theater's groundfloor | 5h | 2012-04-11 14:36 | 2012-04-12 11:06 | 92 | 10.57d |  | 1st official in construction; Specializated pawn in construction [300%]; Bricks [893.11 pce]; Cement mortar [0.34 m3] | 20h | 774.03 |
| 94 | 8.9 | **Theater's concrete beam** | 28.69d | 2012-04-03 07:30 | 2012-05-15 13:30 |  | 55.65d |  |  | 28.5h | 2,508.95 |
| 95 | 8.9.1 | Placement of formwork and struts | 2h | 2012-04-03 07:30 | 2012-04-03 09:30 | 65FS+4d | 55.65d | 0d | 1st official in construction; Specializated pawn in construction [500%]; Formwork [39.19 m2]; Strut [6 pce] | 12h | 1,250.52 |
| 96 | 8.9.2 | Placement of armor | 2h | 2012-04-03 09:30 | 2012-04-03 11:30 | 95 | 55.65d | 0d | Official armor assembler; Ordinary armor assembler pawn [300%]; Iron [410.4 kg] | 8h | 622.1 |
| 97 | 8.9.3 | Concrete placing/Vibration | 0.5h | 2012-04-03 12:00 | 2012-04-03 12:30 | 96 | 55.65d | 0d | 1st official in construction; Ordinary pawn in construction [200%]; Concrete [5.98 m3]; Mixer truck; Vibrator | 2.5h | 461.84 |
| 98 | 8.9.4 | Take away formwork | 1h | 2012-05-15 12:30 | 2012-05-15 13:30 | 97FS+28d | 55.65d | 28.15d | 1st official in construction; Specializated pawn in construction [500%] | 6h | 174.48 |
| 99 | 8.10 | Brick walls between gym pillars in 2nd level | 31h | 2012-04-16 09:12 | 2012-04-20 08:12 | 59, 52 | 105.29d |  | 1st official in construction; Specializated pawn in construction [300%]; Bricks [5921 pce]; Cement mortar [2.25 m3] | 124h | 4,880.6 |
| 100 | 8.11 | **Elevator stairs (until 1st floor)** | 7.88d | 2012-04-11 14:36 | 2012-04-23 13:36 |  | 80.49d |  |  | 25.5h | 1,848.25 |
| 101 | 8.11.1 | Placement of formwork and struts | 0.5h | 2012-04-11 14:36 | 2012-04-11 15:06 | 92 | 80.49d | 0d | 1st official in construction; Specializated pawn in construction [500%]; Formwork [8.84 m2]; Strut [11 pce] | 3h | 397.39 |
| 102 | 8.11.2 | Placement of armor | 0.5h | 2012-04-11 15:06 | 2012-04-12 07:06 | 101 | 80.49d | 0d | Official armor assembler; Ordinary armor assembler pawn [300%]; Iron [410.4 kg] | 2h | 435.62 |
| 103 | 8.11.3 | Concrete placing/Vibration | 0.5h | 2012-04-12 07:06 | 2012-04-12 07:36 | 102 | 80.49d | 0d | 1st official in construction; Ordinary pawn in construction [200%]; Concrete [5.98 m3]; Mixer truck; Vibrator | 2.5h | 461.84 |
| 104 | 8.11.4 | Take away formwork | 0.5h | 2012-04-23 07:36 | 2012-04-23 08:06 | 103FS+7d | 80.49d | 0d | 1st official in construction; Specializated pawn in construction [500%] | 3h | 87.24 |
| 105 | 8.11.5 | Steps construction | 5h | 2012-04-23 08:06 | 2012-04-23 13:36 | 104 | 80.49d | 0d | 1st official in construction; Ordinary pawn in construction [200%]; Bricks [144 pce]; Cement mortar [0.07 m3] | 15h | 466.15 |
| 106 | 9 | **F.08 - Horizontal elements** | 20.6d | 2012-04-12 10:24 | 2012-05-14 07:12 |  | 1.66d |  |  | 443.5h | 43,868.04 |
| 107 | 9.1 | **1st floor in gym** | 9d | 2012-04-16 07:42 | 2012-04-27 07:42 |  | 0d |  |  | 74h | 8,475.06 |
| 108 | 9.1.1 | Placement of formwork and struts | 5.5h | 2012-04-16 07:42 | 2012-04-16 13:42 | 41, 54 | 0d |  | 1st official in construction; Specializated pawn in construction [500%]; Formwork [133.31 m2]; Strut [66 pce] | 33h | 4,531.1 |
| 109 | 9.1.2 | Placement of armor | 4.5h | 2012-04-16 13:42 | 2012-04-17 09:42 | 108 | 0d |  | Official armor assembler; Ordinary armor assembler pawn [300%]; Iron [1066.48 kg] | 18h | 1,529.94 |
| 110 | 9.1.3 | Concrete placing/Vibration | 2.5h | 2012-04-17 09:42 | 2012-04-17 12:42 | 109 | 0d |  | 1st official in construction; Ordinary pawn in construction [200%]; Concrete [26.66 m3]; Mixer truck; Vibrator | 12.5h | 2,110.51 |
| 111 | 9.1.4 | Take away formwork | 3.5h | 2012-04-26 12:42 | 2012-04-27 07:42 | 110FS+7d | 0d |  | 1st official in construction; Ordinary pawn in construction [200%] | 10.5h | 303.52 |

| ID | WBS | Task | Duration | Start | Finish | Predecessors | Total slack | Free slack | Resources | Work | Cost |
| --- | --- | --- | --- | --- | --- | --- | --- | --- | --- | --- | --- |
| 112 | 9.2 | **Gym's roof** | 3.25d | 2012-04-16 09:12 | 2012-04-19 11:12 |  | 105.91d |  |  | 78h | 9,447.18 |
| 113 | 9.2.1 | Placement of gym's metallic beams | 14.5h | 2012-04-16 09:12 | 2012-04-18 07:42 | 59FS+4d | 105.91d | 0d | 1st official in iron; Specialist in iron [200%]; Metallic beam [4 pce] | 43.5h | 1,102.07 |
| 114 | 9.2.2 | Gym's roof metallic elements placement | 11.5h | 2012-04-18 07:42 | 2012-04-19 11:12 | 113 | 105.91d |  | 1st official in iron; Specialist in iron [200%]; Galvanized steel sheet [459.03 m2] | 34.5h | 8,345.12 |
| 115 | 9.3 | **Classes roof (except 2, for tower crane disassembly)** | 4.06d | 2012-04-12 10:24 | 2012-04-18 10:54 |  | 93.54d |  |  | 168h | 13,038.3 |
| 116 | 9.3.1 | Placement of prefabricated slabs and struts | 32h | 2012-04-12 10:24 | 2012-04-18 10:24 | 82 | 93.54d | 0d | 1st official in construction; Specializated pawn in construction [300%]; Prefabricated slab [213.38 m2]; Strut [24 pce] | 128h | 10,825.04 |
| 117 | 9.3.2 | Placement of armor | 14.25h | 2012-04-16 10:24 | 2012-04-18 08:39 | 116SS+5% | 93.76d | 0.22d | Official armor assembler; Ordinary armor assembler pawn [200%]; Iron [853.12 kg] | 38h | 1,957.38 |
| 118 | 9.3.3 | Placement of concrete in slab joints | 0.5h | 2012-04-18 10:24 | 2012-04-18 10:54 | 116, 117 | 93.54d | 44.01d | 1st official in construction; Specializated pawn in construction; Concrete [2.85 m3]; Mixer truck; Vibrator | 2h | 255.88 |
| 119 | 9.4 | **Theater's 1st floor** | 9.94d | 2012-04-27 07:42 | 2012-05-14 07:12 |  | 0d |  |  | 123.5h | 12,907.49 |
| 120 | 9.4.1 | Placement of formwork | 7h | 2012-04-27 07:42 | 2012-04-27 15:12 | 93, 111 | 0d |  | 1st official in construction; Specializated pawn in construction [500%]; Formwork [164.34 m2] | 42h | 4,723.45 |
| 121 | 9.4.2 | Placement of armor | 11.5h | 2012-04-27 11:12 | 2012-04-30 15:12 | 120SS+5% | 0d |  | Official armor assembler; Ordinary armor assembler pawn [200%]; Iron [2793.78 kg] | 34.5h | 3,614.6 |
| 122 | 9.4.3 | Concrete placing/Vibration | 4h | 2012-04-30 15:12 | 2012-05-02 10:42 | 121 | 0d |  | 1st official in construction; Ordinary pawn in construction [200%]; Concrete [49.3 m3]; Mixer truck; Vibrator | 20h | 3,784.29 |
| 123 | 9.4.4 | Take away formwork | 4.5h | 2012-05-11 10:42 | 2012-05-14 07:12 | 122FS+7d | 0d |  | 1st official in construction; Specializated pawn in construction [500%] | 27h | 785.16 |
| 124 | 10 | **F.09 - Theater vertical elements (1st floor)** | 30.95d | 2012-04-06 13:06 | 2012-05-24 12:42 |  | 22.25d |  |  | 449h | 40,537.87 |
| 125 | 10.1 | **Concrete walls zone 7-8** | 6d | 2012-05-14 07:12 | 2012-05-23 07:12 |  | 0d |  |  | 136h | 11,780.3 |
| 126 | 10.1.1 | Scaffold installation | 4.5h | 2012-05-14 07:12 | 2012-05-14 12:12 | 123 | 0d |  | 1st official in construction; Specializated pawn in construction; Scaffold [15 pce] | 9h | 633.99 |
| 127 | 10.1.2 | Inside formwork's placement | 4.5h | 2012-05-14 07:12 | 2012-05-14 12:12 | 126SS | 0d |  | 1st official in construction; Specializated pawn in construction [500%]; Formwork [102.48 m2] | 27h | 2,969.01 |
| 128 | 10.1.3 | Placement of armor | 7.5h | 2012-05-14 12:12 | 2012-05-15 11:12 | 127 | 0d |  | Official armor assembler; Ordinary armor assembler pawn [300%]; Iron [1844.64 kg] | 30h | 2,611.02 |
| 129 | 10.1.4 | Outside formwork's placement | 4.5h | 2012-05-15 11:12 | 2012-05-16 07:42 | 128 | 0d |  | 1st official in construction; Specializated pawn in construction [500%]; Formwork [102.48 m2] | 27h | 2,969.01 |
| 130 | 10.1.5 | Concrete placing/Vibration | 2h | 2012-05-16 07:42 | 2012-05-16 09:42 | 129 | 0d |  | 1st official in construction; Ordinary pawn in construction [200%]; Concrete [20.5 m3]; Mixer truck; Vibrator | 10h | 1,637.62 |
| 131 | 10.1.6 | Take away formwork | 5.5h | 2012-05-22 09:42 | 2012-05-23 07:12 | 130FS+3d | 0d |  | 1st official in construction; Specializated pawn in construction [500%] | 33h | 959.64 |
| 132 | 10.2 | **Concrete walls zone 10-11** | 7.06d | 2012-05-14 12:12 | 2012-05-24 12:42 |  | 8d |  |  | 183.5h | 16,015.83 |
| 133 | 10.2.1 | Scaffold installation | 6h | 2012-05-14 12:12 | 2012-05-15 09:42 | 92FS+4d, 123, 126 | 8d | 0d | 1st official in construction; Specializated pawn in construction; Scaffold [20 pce] | 12h | 845.32 |
| 134 | 10.2.2 | Inside formwork's placement | 6h | 2012-05-14 12:12 | 2012-05-15 09:42 | 133SS | 8d | 0d | 1st official in construction; Specializated pawn in construction [500%]; Formwork [140.14 m2] | 36h | 4,033.26 |
| 135 | 10.2.3 | Placement of armor | 10.5h | 2012-05-15 09:42 | 2012-05-16 12:42 | 134 | 8d | 0d | Official armor assembler; Ordinary armor assembler pawn [300%]; Iron [2522.52 kg] | 42h | 3,600.85 |
| 136 | 10.2.4 | Outside formwork's placement | 6h | 2012-05-16 12:42 | 2012-05-18 10:12 | 135 | 8d | 0d | 1st official in construction; Specializated pawn in construction [500%]; Formwork [140.14 m2] | 36h | 4,033.26 |
| 137 | 10.2.5 | Concrete placing/Vibration | 2.5h | 2012-05-18 10:12 | 2012-05-18 13:12 | 136 | 8d | 0d | 1st official in construction; Ordinary pawn in construction [200%]; Concrete [28.03 m3]; Mixer truck; Vibrator | 12.5h | 2,194.53 |
| 138 | 10.2.6 | Take away formwork | 7.5h | 2012-05-23 13:12 | 2012-05-24 12:42 | 137FS+3d | 8d | 0d | 1st official in construction; Specializated pawn in construction [500%] | 45h | 1,308.6 |

| ID | WBS | Task | Duration | Start | Finish | Predecessors | Total slack | Free slack | Resources | Work | Cost |
| --- | --- | --- | --- | --- | --- | --- | --- | --- | --- | --- | --- |
| 139 | 10.3 | **Party walls in theater's zone (until roof)** | 6.56d | 2012-04-06 13:06 | 2012-04-18 09:06 |  | 46.64d |  |  | 129.5h | 12,741.75 |
| 140 | 10.3.1 | Placement of insulation in existent walls as lost formwork | 8.5h | 2012-04-06 13:06 | 2012-04-10 13:36 | 81FS+4d | 46.64d | 0d | 1st official in construction; Ordinary pawn in construction; Insulation [211.2 m2] | 17h | 1,783.44 |
| 141 | 10.3.2 | Placement of armor | 2h | 2012-04-10 13:36 | 2012-04-11 07:06 | 140 | 46.64d | 0d | Official armor assembler; Ordinary armor assembler pawn [300%]; Iron [464.64 kg] | 8h | 671.46 |
| 142 | 10.3.3 | Placement of external formwork | 9h | 2012-04-11 07:06 | 2012-04-12 08:06 | 141 | 46.64d | 0d | 1st official in construction; Specializated pawn in construction [500%]; Formwork [211.2 m2] | 54h | 6,070.99 |
| 143 | 10.3.4 | Concrete placing/Vibration | 3.5h | 2012-04-12 08:06 | 2012-04-12 12:06 | 142 | 46.64d | 0d | 1st official in construction; Ordinary pawn in construction [200%]; Concrete [42.24 m3]; Mixer truck; Vibrator | 17.5h | 3,256.21 |
| 144 | 10.3.5 | Take away formwork | 5.5h | 2012-04-17 12:06 | 2012-04-18 09:06 | 143FS+3d | 46.64d |  | 1st official in construction; Specializated pawn in construction [500%] | 33h | 959.64 |
| 145 | 11 | **F.10 - Theater horizontal elements (1st to 2nd level)** | 35.14d | 2012-04-23 13:36 | 2012-06-14 14:42 |  | 23.26d |  |  | 189.5h | 17,462.27 |
| 146 | 11.1 | **Podium level** | 10.25d | 2012-05-31 12:42 | 2012-06-14 14:42 |  | 8d |  |  | 127h | 12,465.29 |
| 147 | 11.1.1 | Placement of formwork and struts | 6h | 2012-05-31 12:42 | 2012-06-01 10:12 | 138FS+4d | 8d | 0d | 1st official in construction; Specializated pawn in construction [500%]; Formwork [142.79 m2]; Strut [40 pce] | 36h | 4,532.53 |
| 148 | 11.1.2 | Placement of armor | 13h | 2012-06-01 10:12 | 2012-06-05 07:12 | 147 | 8d | 0d | Official armor assembler; Ordinary armor assembler pawn [300%]; Iron [3141.38 kg] | 52h | 4,474.82 |
| 149 | 11.1.3 | Concrete placing/Vibration | 3h | 2012-06-05 07:12 | 2012-06-05 10:12 | 148 | 8d | 0d | 1st official in construction; Ordinary pawn in construction [200%]; Concrete [35.7 m3]; Mixer truck; Vibrator | 15h | 2,760.02 |
| 150 | 11.1.4 | Take away formwork | 4h | 2012-06-14 10:12 | 2012-06-14 14:42 | 149FS+7d | 8d |  | 1st official in construction; Specializated pawn in construction [500%] | 24h | 697.92 |
| 151 | 11.2 | **Technical room floor (over WC)** | 7.88d | 2012-05-30 07:12 | 2012-06-08 14:42 |  | 0d |  |  | 37h | 3,571.48 |
| 152 | 11.2.1 | Placement of formwork and struts | 2.5h | 2012-05-30 07:12 | 2012-05-30 09:42 | 131FS+4d | 0d |  | 1st official in construction; Specializated pawn in construction [500%]; Formwork [55.8 m2]; Strut [14 pce] | 15h | 1,780.28 |
| 153 | 11.2.2 | Placement of armor | 2h | 2012-05-30 09:42 | 2012-05-30 12:12 | 152 | 0d |  | Official armor assembler; Ordinary armor assembler pawn [300%]; Iron [446.4 kg] | 8h | 654.86 |
| 154 | 11.2.3 | Concrete placing/Vibration | 1h | 2012-05-30 12:12 | 2012-05-30 13:12 | 153 | 0d |  | 1st official in construction; Ordinary pawn in construction [200%]; Concrete [11.16 m3]; Mixer truck; Vibrator | 5h | 874.62 |
| 155 | 11.2.4 | Take away formwork | 1.5h | 2012-06-08 13:12 | 2012-06-08 14:42 | 154FS+7d | 0d |  | 1st official in construction; Specializated pawn in construction [500%] | 9h | 261.72 |
| 156 | 11.3 | **Elevator stairs (until 2nd floor)** | 7.88d | 2012-04-23 13:36 | 2012-05-04 12:36 |  | 80.49d |  |  | 25.5h | 1,425.5 |
| 157 | 11.3.1 | Placement of formwork and struts | 0.5h | 2012-04-23 13:36 | 2012-04-23 14:06 | 105 | 80.49d | 0d | 1st official in construction; Specializated pawn in construction [500%]; Formwork [8.84 m2]; Strut [22 pce] | 3h | 519.16 |
| 158 | 11.3.2 | Placement of armor | 0.5h | 2012-04-23 14:06 | 2012-04-23 14:36 | 157 | 80.49d | 0d | Official armor assembler; Ordinary armor assembler pawn [300%]; Iron [95.76 kg] | 2h | 149.3 |
| 159 | 11.3.3 | Concrete placing/Vibration | 0.5h | 2012-04-23 14:36 | 2012-04-23 15:06 | 158 | 80.49d | 0d | 1st official in construction; Ordinary pawn in construction [200%]; Concrete [1.77 m3]; Mixer truck; Vibrator | 2.5h | 203.64 |
| 160 | 11.3.4 | Take away formwork | 0.5h | 2012-05-03 15:06 | 2012-05-04 07:06 | 159FS+7d | 80.49d | 0d | 1st official in construction; Specializated pawn in construction [500%] | 3h | 87.24 |
| 161 | 11.3.5 | Steps construction | 5h | 2012-05-04 07:06 | 2012-05-04 12:36 | 160 | 80.49d | 32.83d | 1st official in construction; Ordinary pawn in construction [200%]; Bricks [144 pce]; Cement mortar [0.07 m3] | 15h | 466.15 |
| 162 | 12 | **F.11 - Theater vertical elements (2nd floor)** | 23.69d | 2012-05-31 12:42 | 2012-07-04 09:42 |  | 6.25d |  |  | 244.5h | 22,129.7 |
| 163 | 12.1 | **Concrete walls zone 7-8** | 8d | 2012-06-08 14:42 | 2012-06-20 14:42 |  | 0d |  |  | 140.5h | 13,479.1 |
| 164 | 12.1.1 | Scaffold installation | 4.5h | 2012-06-08 14:42 | 2012-06-11 10:42 | 155 | 0d |  | 1st official in construction; Specializated pawn in construction; Scaffold [15 pce] | 9h | 633.99 |
| 165 | 12.1.2 | Placement of armor | 15h | 2012-06-11 10:42 | 2012-06-13 09:42 | 164 | 0d |  | Official armor assembler; Ordinary armor assembler pawn [300%]; Iron [3672.81 kg] | 60h | 5,207.06 |
| 166 | 12.1.3 | Formwork's placement | 5.5h | 2012-06-13 09:42 | 2012-06-14 07:12 | 165 | 0d |  | 1st official in construction; Specializated pawn in construction [500%]; Formwork [136.05 m2] | 33h | 3,858.87 |
| 167 | 12.1.4 | Concrete placing/Vibration | 3.5h | 2012-06-14 07:12 | 2012-06-14 10:42 | 166 | 0d |  | 1st official in construction; Ordinary pawn in construction [200%]; Concrete [40.81 m3]; Mixer truck; Vibrator | 17.5h | 3,168.51 |
| 168 | 12.1.5 | Take away formwork | 3.5h | 2012-06-20 10:42 | 2012-06-20 14:42 | 167FS+4d | 0d |  | 1st official in construction; Specializated pawn in construction [500%] | 21h | 610.68 |

| ID | WBS | Task | Duration | Start | Finish | Predecessors | Total slack | Free slack | Resources | Work | Cost |
| --- | --- | --- | --- | --- | --- | --- | --- | --- | --- | --- | --- |
| 169 | 12.2 | **Concrete walls in elevator shaft** | 4.38d | 2012-05-31 12:42 | 2012-06-07 07:12 |  | 47.66d |  |  | 58h | 4,948.57 |
| 170 | 12.2.1 | Placement of armor | 3.5h | 2012-05-31 12:42 | 2012-06-01 07:42 | 138FS+4d | 47.66d | 0d | Official armor assembler; Ordinary armor assembler pawn [300%]; Iron [805.5 kg] | 14h | 1,168.12 |
| 171 | 12.2.2 | Placement of formwork | 4h | 2012-06-01 07:42 | 2012-06-01 12:12 | 170 | 47.66d | 0d | 1st official in construction; Specializated pawn in construction [500%]; Formwork [89.5 m2] | 24h | 2,605.16 |
| 172 | 12.2.3 | Concrete placing/Vibration | 1h | 2012-06-01 12:12 | 2012-06-01 13:12 | 171 | 47.66d | 0d | 1st official in construction; Ordinary pawn in construction [200%]; Concrete [8.95 m3]; Mixer truck; Vibrator | 5h | 739.08 |
| 173 | 12.2.4 | Take away formwork | 2.5h | 2012-06-06 13:12 | 2012-06-07 07:12 | 172FS+3d | 47.66d | 0d | 1st official in construction; Specializated pawn in construction [500%] | 15h | 436.2 |
| 174 | 12.3 | **Engine room floor** | 7.44d | 2012-06-13 07:12 | 2012-06-22 10:42 |  | 47.66d |  |  | 17.5h | 1,414 |
| 175 | 12.3.1 | Placement of formwork and struts | 1h | 2012-06-13 07:12 | 2012-06-13 08:12 | 173FS+4d | 47.66d | 0d | 1st official in construction; Specializated pawn in construction [500%]; Formwork [14.8 m2]; Strut [7 pce] | 6h | 567.36 |
| 176 | 12.3.2 | Placement of armor | 1.5h | 2012-06-13 08:12 | 2012-06-13 09:42 | 175 | 47.66d | 0d | Official armor assembler; Ordinary armor assembler pawn [300%]; Iron [325.6 kg] | 6h | 482.78 |
| 177 | 12.3.3 | Concrete placing/Vibration | 0.5h | 2012-06-13 09:42 | 2012-06-13 10:12 | 176 | 47.66d | 0d | 1st official in construction; Ordinary pawn in construction [200%]; Concrete [2.96 m3]; Mixer truck; Vibrator | 2.5h | 276.63 |
| 178 | 12.3.4 | Take away formwork | 0.5h | 2012-06-22 10:12 | 2012-06-22 10:42 | 177FS+7d | 47.66d | 0d | 1st official in construction; Specializated pawn in construction [500%] | 3h | 87.24 |
| 179 | 12.4 | **Elevator stairs (until engine room)** | 7.88d | 2012-06-22 10:42 | 2012-07-04 09:42 |  | 47.66d |  |  | 25.5h | 1,288.03 |
| 180 | 12.4.1 | Placement of formwork and struts | 0.5h | 2012-06-22 10:42 | 2012-06-22 11:12 | 178, 161 | 47.66d | 0d | 1st official in construction; Specializated pawn in construction [500%]; Formwork [8.84 m2]; Strut [11 pce] | 3h | 397.39 |
| 181 | 12.4.2 | Placement of armor | 0.5h | 2012-06-22 11:12 | 2012-06-22 12:12 | 180 | 47.66d | 0d | Official armor assembler; Ordinary armor assembler pawn [300%]; Iron [95.76 kg] | 2h | 149.3 |
| 182 | 12.4.3 | Concrete placing/Vibration | 0.5h | 2012-06-22 12:12 | 2012-06-22 12:42 | 181 | 47.66d | 0d | 1st official in construction; Ordinary pawn in construction [200%]; Concrete [1.77 m3]; Mixer truck; Vibrator | 2.5h | 203.64 |
| 183 | 12.4.4 | Take away formwork | 0.5h | 2012-07-03 12:42 | 2012-07-03 13:12 | 182FS+7d | 47.66d | 0d | 1st official in construction; Specializated pawn in construction [500%] | 3h | 87.24 |
| 184 | 12.4.5 | Steps construction | 5h | 2012-07-03 13:12 | 2012-07-04 09:42 | 183 | 47.66d | 0d | 1st official in construction; Ordinary pawn in construction [200%]; Bricks [72 pce]; Cement mortar [0.04 m3] | 15h | 450.45 |
| 185 | 12.5 | Move crane to the street | 3h | 2012-06-20 14:42 | 2012-06-21 09:12 | 168 | 49.53d | 0d | Cost crane setup/remove [3.3%]; Crane subcontractor | 3h | 1,000 |
| 186 | 13 | **F.12 - Classes' elements** | 14.63d | 2012-06-21 09:12 | 2012-07-12 14:45 |  | 49.53d |  |  | 417.5h | 29,433.61 |
| 187 | 13.1 | **Classes roof in class 2** | 1.44d | 2012-06-21 09:12 | 2012-06-22 13:12 |  | 49.53d |  |  | 51h | 4,314.49 |
| 188 | 13.1.1 | Placement of prefabricated slabs and struts (class 2) | 11.5h | 2012-06-21 09:12 | 2012-06-22 13:12 | 185 | 49.53d | 0d | 1st official in construction; Specializated pawn in construction [200%]; Prefabricated slab [73.81 m2]; Strut [8 pce] | 34.5h | 3,458.57 |
| 189 | 13.1.2 | Placement of armor (class 2) | 3.5h | 2012-06-21 15:27 | 2012-06-22 10:27 | 188SS+5% | 49.53d | 0d | Official armor assembler; Ordinary armor assembler pawn [300%]; Iron [295.24 kg] | 14h | 703.79 |
| 190 | 13.1.3 | Placement of concrete in slab joints (class 2) | 0.5h | 2012-06-22 10:27 | 2012-06-22 10:57 | 189 | 49.53d | 0d | 1st official in construction; Ordinary pawn in construction [200%]; Concrete [0.93 m3]; Mixer truck; Vibrator | 2.5h | 152.13 |
| 191 | 13.2 | **Perimetral concrete beam** | 3.62d | 2012-06-22 10:57 | 2012-06-28 07:57 |  | 49.53d |  |  | 27.5h | 2,400.78 |
| 192 | 13.2.1 | Placement of formwork and struts | 2h | 2012-06-22 10:57 | 2012-06-22 13:27 | 190, 118 | 49.53d | 0d | 1st official in construction; Specializated pawn in construction [500%]; Formwork [45.12 m2]; Strut [13 pce] | 12h | 1,454.38 |
| 193 | 13.2.2 | Placement of armor | 1h | 2012-06-22 13:27 | 2012-06-22 14:27 | 192 | 49.53d | 0d | Official armor assembler; Ordinary armor assembler pawn [300%]; Iron [249.12 kg] | 4h | 351.02 |
| 194 | 13.2.3 | Concrete placing/Vibration | 0.5h | 2012-06-22 14:27 | 2012-06-22 14:57 | 193 | 49.53d | 0d | 1st official in construction; Ordinary pawn in construction [200%]; Concrete [3.89 m3]; Mixer truck; Vibrator | 2.5h | 333.66 |
| 195 | 13.2.4 | Take away formwork | 1.5h | 2012-06-27 14:57 | 2012-06-28 07:57 | 194FS+3d | 49.53d | 0d | 1st official in construction; Specializated pawn in construction [500%] | 9h | 261.72 |

| ID | WBS | Task | Duration | Start | Finish | Predecessors | Total slack | Free slack | Resources | Work | Cost |
| --- | --- | --- | --- | --- | --- | --- | --- | --- | --- | --- | --- |
| 196 | 13.3 | **Stairs to terrace** | 0.5d | 2012-07-04 07:57 | 2012-07-04 12:27 |  | 53.82d |  |  | 12h | 952.41 |
| 197 | 13.3.1 | Placement of prefabricated stairs' slabs with struts | 4h | 2012-07-04 07:57 | 2012-07-04 12:27 | 195FS+4d, 69 | 53.82d | 0d | 1st official in construction; Specializated pawn in construction [200%]; Prefabricated slab [15 m2]; Strut [11 pce] | 12h | 952.41 |
| 198 | 13.4 | **Terrace construction** | 9.79d | 2012-06-28 07:57 | 2012-07-12 14:45 |  | 49.53d |  |  | 327h | 21,765.93 |
| 199 | 13.4.1 | Placement of vapour barrier | 2h | 2012-06-28 07:57 | 2012-06-28 09:57 | 195 | 49.53d | 0d | 1st official in construction; Ordinary pawn in construction [200%]; Vapour barrier (Polyethilene plastic sheet) [316.59 m2] | 6h | 569.18 |
| 200 | 13.4.2 | Slope formation | 2.5h | 2012-06-28 09:57 | 2012-06-28 12:57 | 199 | 49.53d | 0d | 1st official in construction; Ordinary pawn in construction [200%]; Lean concrete [29.56 m3] | 7.5h | 1,685.05 |
| 201 | 13.4.3 | Placement of insulation | 12.5h | 2012-06-29 12:57 | 2012-07-03 08:57 | 200FS+1d | 49.53d | 0d | 1st official in construction; Ordinary pawn in construction [200%]; Insulation [302.62 m2] | 37.5h | 2,929.98 |
| 202 | 13.4.4 | Placement of EPDM | 3.5h | 2012-07-02 08:12 | 2012-07-02 12:12 | 201SS+3% | 49.53d | 0d | 1st official in construction; Ordinary pawn in construction [200%]; EPDM [302.62 m2] | 10.5h | 3,072.49 |
| 203 | 13.4.5 | Placement of adjustable supports | 27.5h | 2012-07-02 09:15 | 2012-07-05 13:15 | 202SS+3% | 49.53d | 0d | 1st official in construction; Ordinary pawn in construction [200%]; Adjustable support [302.62 m2] | 82.5h | 5,789.27 |
| 204 | 13.4.6 | Placement of tiles | 61h | 2012-07-02 09:15 | 2012-07-12 14:45 | 203SS | 49.53d |  | 1st official in construction; Ordinary pawn in construction [200%]; Tiles [302.62 m2] | 183h | 7,719.96 |
| 205 | 14 | **F.13 - Theater elements** | 66.16d | 2012-06-08 14:42 | 2012-09-13 07:30 |  | 6.38d |  |  | 1269h | 131,036.37 |
| 206 | 14.1 | **Elevator shaft roof** | 8.06d | 2012-07-03 13:12 | 2012-07-16 13:42 |  | 47.66d |  |  | 36.5h | 3,701.5 |
| 207 | 14.1.1 | Placement of formwork and struts | 1.5h | 2012-07-03 13:12 | 2012-07-03 14:42 | 184SS | 47.66d | 0d | 1st official in construction; Specializated pawn in construction [500%]; Formwork [36.3 m2]; Strut [10 pce] | 9h | 1,145.97 |
| 208 | 14.1.2 | Placement of armor | 3.5h | 2012-07-03 14:42 | 2012-07-04 09:42 | 207 | 47.66d | 0d | Official armor assembler; Ordinary armor assembler pawn [300%]; Iron [792 kg] | 14h | 1,155.84 |
| 209 | 14.1.3 | Concrete placing/Vibration | 1h | 2012-07-04 09:42 | 2012-07-04 10:42 | 208 | 47.66d | 0d | 1st official in construction; Ordinary pawn in construction [200%]; Concrete [7.62 m3]; Mixer truck; Vibrator | 5h | 657.51 |
| 210 | 14.1.4 | Take away formwork | 1h | 2012-07-16 10:42 | 2012-07-16 12:12 | 209FS+7d | 47.66d | 0d | 1st official in construction; Specializated pawn in construction [500%] | 6h | 174.48 |
| 211 | 14.1.5 | Placement of EPDM | 0.5h | 2012-07-16 12:12 | 2012-07-16 12:42 | 210 | 47.66d | 0d | 1st official in construction; Ordinary pawn in construction [200%]; EPDM [36.3 m2] | 1.5h | 375.5 |
| 212 | 14.1.6 | Placement of grave | 1h | 2012-07-16 12:42 | 2012-07-16 13:42 | 211 | 47.66d |  | Ordinary pawn in construction; Grave [36.3 m2] | 1h | 192.18 |
| 213 | 14.2 | **Theater wall 1st part** | 19d | 2012-06-26 14:42 | 2012-07-24 14:42 |  | 0d |  |  | 502h | 46,832.08 |
| 214 | 14.2.1 | Scaffold installation | 7h | 2012-06-26 14:42 | 2012-06-27 13:42 | 168FS+4d, 150, 144 | 0d |  | 1st official in construction; Specializated pawn in construction; Scaffold [22 pce] | 14h | 953.34 |
| 215 | 14.2.2 | Inside formwork's placement | 14.5h | 2012-06-26 14:42 | 2012-06-28 13:12 | 214SS | 0d |  | 1st official in construction; Specializated pawn in construction [500%]; Formwork [361.83 m2] | 87h | 10,240.56 |
| 216 | 14.2.3 | Placement of armor | 39.5h | 2012-06-28 13:12 | 2012-07-05 12:42 | 215 | 0d |  | Official armor assembler; Ordinary armor assembler pawn [300%]; Iron [9769.36 kg] | 158h | 13,800.76 |
| 217 | 14.2.4 | Outside formwork's placement | 14.5h | 2012-07-05 12:42 | 2012-07-09 10:42 | 216 | 0d |  | 1st official in construction; Specializated pawn in construction [500%]; Formwork [361.83 m2] | 87h | 10,240.56 |
| 218 | 14.2.5 | Concrete placing/Vibration | 9h | 2012-07-09 10:42 | 2012-07-10 12:12 | 217 | 0d |  | 1st official in construction; Ordinary pawn in construction [200%]; Concrete [108.55 m3]; Mixer truck; Vibrator | 45h | 8,368.99 |
| 219 | 14.2.6 | Take away formwork | 18.5h | 2012-07-20 12:12 | 2012-07-24 14:42 | 218FS+7d | 0d |  | 1st official in construction; Specializated pawn in construction [500%] | 111h | 3,227.88 |

| ID | WBS | Task | Duration | Start | Finish | Predecessors | Total slack | Free slack | Constraint | Resources | Work | Cost |
| --- | --- | --- | --- | --- | --- | --- | --- | --- | --- | --- | --- | --- |
| 220 | 14.3 | **Theater wall 2nd part** | 12.25d | 2012-07-24 14:42 | 2012-08-10 08:12 |  | 0d |  |  |  | 224h | 20,780.01 |
| 221 | 14.3.1 | Scaffold installation | 5h | 2012-07-24 14:42 | 2012-07-25 11:12 | 219 | 0d |  |  | 1st official in construction; Specializated pawn in construction; Scaffold [22 pce] | 10h | 835.9 |
| 222 | 14.3.2 | Inside formwork's placement | 6.5h | 2012-07-24 14:42 | 2012-07-25 13:12 | 221SS | 0d |  |  | 1st official in construction; Specializated pawn in construction [500%]; Formwork [156.63 m2] | 39h | 4,471.91 |
| 223 | 14.3.3 | Placement of armor | 17h | 2012-07-25 13:12 | 2012-07-27 14:12 | 222 | 0d |  |  | Official armor assembler; Ordinary armor assembler pawn [300%]; Iron [4229.01 kg] | 68h | 5,961.84 |
| 224 | 14.3.4 | Outside formwork's placement | 6.5h | 2012-07-27 14:12 | 2012-07-30 12:42 | 223 | 0d |  |  | 1st official in construction; Specializated pawn in construction [500%]; Formwork [156.63 m2] | 39h | 4,471.91 |
| 225 | 14.3.5 | Concrete placing/Vibration | 4h | 2012-07-30 12:42 | 2012-07-31 08:12 | 224 | 0d |  |  | 1st official in construction; Ordinary pawn in construction [200%]; Concrete [46.99 m3]; Mixer truck; Vibrator | 20h | 3,642.62 |
| 226 | 14.3.6 | Take away formwork | 8h | 2012-08-09 08:12 | 2012-08-10 08:12 | 225FS+7d | 0d |  |  | 1st official in construction; Specializated pawn in construction [500%] | 48h | 1,395.84 |
| 227 | 14.4 | **Theater floor** | 3.75d | 2012-06-26 14:42 | 2012-07-02 12:42 |  | 27.5d |  |  |  | 90h | 9,430.68 |
| 228 | 14.4.1 | Placement of prefabricated slabs with struts | 30h | 2012-06-26 14:42 | 2012-07-02 12:42 | 168FS+4d, 98 | 27.5d |  |  | 1st official in construction; Specializated pawn in construction [200%]; Prefabricated slab [198.69 m2]; Strut [40 pce] | 90h | 9,430.68 |
| 229 | 14.5 | **Theater stairs** | 1d | 2012-06-08 14:42 | 2012-06-11 14:42 |  | 71.54d |  |  |  | 24h | 2,501.64 |
| 230 | 14.5.1 | Placement of prefabricated slabs with struts | 8h | 2012-06-08 14:42 | 2012-06-11 14:42 | 155 | 71.54d |  |  | 1st official in construction; Specializated pawn in construction [200%]; Prefabricated slab [41.04 m2]; Strut [44 pce] | 24h | 2,501.64 |
| 231 | 14.6 | **Theater roof** | 22.54d | 2012-08-10 08:12 | 2012-09-12 13:00 |  | 0d |  |  |  | 373.5h | 43,719.26 |
| 232 | 14.6.1 | Placement of presfabricated slabs and struts | 62.5h | 2012-08-10 08:12 | 2012-08-22 15:12 | 155, 226, 228 | 0d |  |  | 1st official in construction; Specializated pawn in construction [200%]; Prefabricated slab [414.43 m2]; Strut [100 pce] | 187.5h | 19,847.51 |
| 233 | 14.6.2 | Placement of armor | 18.5h | 2012-08-10 08:12 | 2012-08-14 10:42 | 232SS | 8.62d |  |  | Official armor assembler; Ordinary armor assembler pawn [300%]; Iron [4558.73 kg] | 74h | 6,448.36 |
| 234 | 14.6.3 | Placement of concrete in slabs joints | 4.5h | 2012-08-28 07:42 | 2012-08-28 12:42 | 232FS+4%, 233 | 0d |  |  | 1st official in construction; Ordinary pawn in construction [200%]; Concrete [52.47 m3]; Mixer truck; Vibrator | 22.5h | 4,073.8 |
| 235 | 14.6.4 | Placement of vapour barrier | 2.5h | 2012-08-28 12:42 | 2012-08-28 15:12 | 234 | 0d |  |  | 1st official in construction; Ordinary pawn in construction [200%]; Vapour barrier (Polyethilene plastic sheet) [414.43 m2] | 7.5h | 734.84 |
| 236 | 14.6.5 | Slope formation | 3.5h | 2012-08-28 15:12 | 2012-08-29 10:12 | 235 | 0d |  |  | 1st official in construction; Ordinary pawn in construction [200%]; Lean concrete [41.44 m3] | 10.5h | 2,361.84 |
| 237 | 14.6.6 | Placement of insulation | 17h | 2012-09-10 10:12 | 2012-09-12 11:12 | 236FS+8d | 0d |  |  | 1st official in construction; Ordinary pawn in construction [200%]; Insulation [414.43 m2] | 51h | 4,002.26 |
| 238 | 14.6.7 | Placement of EPDM | 4.5h | 2012-09-11 09:00 | 2012-09-11 14:00 | 237SS+4% | 0d |  |  | 1st official in construction; Ordinary pawn in construction [200%]; EPDM [414.43 m2] | 13.5h | 4,182.27 |
| 239 | 14.6.8 | Placement of grave | 7h | 2012-09-11 14:00 | 2012-09-12 13:00 | 238 | 0d |  |  | Ordinary pawn in construction; Grave [414.43 m2] | 7h | 2,068.37 |
| 240 | 14.7 | Removal of the crane | 3h | 2012-09-12 13:00 | 2012-09-13 07:30 | 239 | 6.38d |  |  | Cost crane setup/remove [3.3%]; Crane subcontractor | 3h | 1,000 |
| 241 | 14.8 | **Glass walls** | 14.28d | 2012-07-04 12:27 | 2012-07-25 14:42 |  | 40.54d |  |  |  | 16h | 3,071.21 |
| 242 | 14.8.1 | Installation of main structure in classes wall | 8h | 2012-07-04 12:27 | 2012-07-05 12:27 | 197 | 53.82d | 13.28d |  | Cost glass wall [3.8%]; Glass wall subcontractor | 8h | 3,071.21 |
| 243 | 14.8.2 | Installation of main structure in theater wall | 8h | 2012-07-24 14:42 | 2012-07-25 14:42 | 219, 242SS | 40.54d |  |  | Cost glass wall [0.1%]; Glass wall subcontractor | 8h |  |
| 244 | 15 | F.14 - Crane costs | 116d | 2012-08-05 15:30 | 2012-09-13 07:30 |  | 6d |  | finish no earlier than 2012-09-13 07:30 | Rental crane | 928h | 5,800 |

| ID | WBS | Task | Type | Duration | Start | Finish | Predecessors | Total slack | Resources | Work | Cost |
| --- | --- | --- | --- | --- | --- | --- | --- | --- | --- | --- | --- |
| 245 | 16 | **F.15 - Comfort installation** |  | 6.75d | 2012-09-12 13:00 | 2012-09-21 10:30 |  | 0d |  | 187.5h | 14,415.43 |
| 246 | 16.1 | Placement of insulation in gym |  | 8.5h | 2012-09-12 13:00 | 2012-09-13 13:30 | 239 | 0d | 1st official in construction; Ordinary pawn in construction [200%]; Insulation [211.97 m2] | 25.5h | 2,030.14 |
| 247 | 16.2 | Placement of insulation in theater |  | 29h | 2012-09-13 07:30 | 2012-09-18 13:00 | 248 | 0d | 1st official in construction; Ordinary pawn in construction [200%]; Insulation [713.31 m2] | 87h | 6,866.07 |
| 248 | 16.3 | Placement of insulation in classes |  | 3h | 2012-09-12 13:00 | 2012-09-13 07:30 | 246SS | 0d | 1st official in construction; Ordinary pawn in construction [200%]; Insulation [70.95 m2] | 9h | 692.96 |
| 249 | 16.4 | Placement of acoustical panels in theater walls |  | 22h | 2012-09-18 13:00 | 2012-09-21 10:30 | 247 | 0d | 1st official in construction; Ordinary pawn in construction [200%]; Acoustical isolation [540.45 m2] | 66h | 4,826.27 |
| 250 | 17 | END | milestone | 0d | 2012-09-21 10:30 | 2012-09-21 10:30 | 204, 243, 249, 114, 212, 230, 239, 99 | 0d |  |  |  |
